# REACTION

Schedule from MS Project, 2008-01-01 to 2012-01-02, status date 2007-04-23, 7 hours a day.
Project plan for proposal
In-JeT ApS

## Calendars

- Standard: Mon-Fri 08:00-12:00, 13:00-17:00; Sat-Sun off.

## Schedule

| ID | WBS | Task | Duration | Start | Finish | Predecessors | Total slack | Free slack | Constraint | Text1 |
| --- | --- | --- | --- | --- | --- | --- | --- | --- | --- | --- |
| 1 | 1 | **WP Project Management** | 1193d? | 2008-01-01 | 2011-12-30 |  | 0.03d |  | start no earlier than 2003-10-10 | Phase 1 |
| 2 | 1.1 | Project initiation | 3.17w | 2008-01-01 | 2008-01-18 |  | 57.31d | 0.15d | start no earlier than 2008-01-01 | Phase 1 |
| 3 | 1.2 | Overall IP management and co-ordination | 238.6w | 2008-01-01 | 2011-12-30 |  | 0.03d |  | finish no earlier than 2011-12-30 | Phase 1 |
| 4 | 1.3 | Project reporting | 223.97w | 2008-03-31 | 2011-12-30 | 2 | 0.03d |  | finish no earlier than 2011-12-30 | Phase 1 |
| 5 | 1.4 | Knowledge management | 223.97w? | 2008-03-31 | 2011-12-30 | 2 | 0.02d |  | start no earlier than 2008-03-31 |  |
| 6 | 1.5 | Quality control and Quality management | 238.6w? | 2008-01-01 | 2011-12-30 |  | 0.02d |  | start no earlier than 2008-01-01 |  |
| 7 | 2 | **WP User Centric Requirements Engineering and Validation** | 1171.29d? | 2008-01-28 | 2012-01-02 |  | 0.01d |  |  | Phase 2 |
| 8 | 2.1 | Scenario thinking | 12.54w | 2008-01-28 | 2008-04-11 | 2 | 1108.6d |  | finish no earlier than 2008-04-11 | Phase 2 |
| 9 | 2.2 | Initial requirements specifications | 50.26w | 2008-02-25 | 2008-12-29 |  | 3.61d | 3.58d | start no earlier than 2008-02-25 | Phase 2 |
| 10 | 2.3 | Evolutionary requirements refinement | 178.71w | 2009-01-01 | 2011-12-30 | 9 | 0.03d |  | finish no earlier than 2011-12-30 | Phase 2 |
| 11 | 2.4 | Validation of platform and services | 90.46w? | 2008-11-03 | 2012-01-02 |  | 0.01d |  | start no earlier than 2008-11-03 |  |
| 12 | 3 | **WP Sensors, Monitoring and Contextualisation** | 1171.27d? | 2008-01-28 | 2011-12-30 |  | 0.03d |  |  | Phase 3 |
| 13 | 3.1 | ePatch body sensor technology | 223.97w | 2008-01-28 | 2011-10-28 |  | 51.46d | 0d | start no earlier than 2008-01-28 | Phase 3 |
| 14 | 3.2 | Continous glucose monitoring sensors | 223.97w | 2008-01-28 | 2011-10-28 | 13SS | 51.46d |  | start no earlier than 2008-01-28 | Phase 3 |
| 15 | 3.3 | Automatic Glycaemic Control | 119.97w | 2009-12-28 | 2011-12-30 | 14SS | 0.03d |  | finish no earlier than 2011-12-30 | Phase 3 |
| 16 | 3.4 | Multiparametric monitoring sensors | 193.8w? | 2008-07-30 | 2011-10-28 | 36 | 51.45d |  | finish no earlier than 2011-10-28 |  |
| 17 | 3.5 | Graphical User Interfaces | 187.4w? | 2008-11-10 | 2011-12-30 |  | 0.02d |  | start no earlier than 2008-11-10 |  |
| 18 | 4 | **WP Data Management and Service Orchestration** | 1171.27d? | 2008-01-28 | 2011-12-30 |  | 0.03d |  |  | Phase 3 |
| 19 | 4.1 | Architectural analysis and description | 55.51w | 2008-01-28 | 2008-12-31 |  | 893.74d |  | start no earlier than 2008-01-28 | Phase 3 |
| 20 | 4.2 | Data structures, taxonomies and ontologies | 223.97w | 2008-01-28 | 2011-10-28 |  | 51.46d |  | start no earlier than 2008-01-28 | Phase 3 |
| 21 | 4.3 | Data management | 223.97w? | 2008-01-28 | 2011-10-28 |  | 51.46d |  | start no earlier than 2008-01-28 |  |
| 22 | 4.4 | Context management framework | 197.69w? | 2008-09-08 | 2011-12-30 |  | 0.03d |  | finish no earlier than 2011-12-30 |  |
| 23 | 4.5 | Rule-based orchestration of services for monitoring and event handling | 174.83w? | 2009-01-26 | 2011-12-30 |  | 0.03d |  | finish no earlier than 2011-12-30 |  |
| 24 | 5 | **WP Network Management and Service Execution** | 1171.27d? | 2008-01-28 | 2011-12-30 |  | 0.03d |  |  | Phase 4 |
| 25 | 5.1 | Network architecture and analysis | 53.69w | 2008-01-28 | 2008-12-22 |  | 902.85d |  | start no earlier than 2008-01-28 | Phase 4 |
| 26 | 5.2 | BAN and PAN network implementation | 190.83w | 2008-08-18 | 2011-10-31 | 25 | 51.44d |  | start no earlier than 2008-08-18 | Phase 4 |
| 27 | 5.3 | Network Management implementation | 201.11w? | 2008-08-18 | 2011-12-30 | 25 | 0.03d |  | finish no earlier than 2011-12-30 | Phase 4 |
| 28 | 5.4 | Network interoperability and service execution | 187.4w? | 2008-11-10 | 2011-12-30 |  | 0.02d |  | start no earlier than 2008-11-10 |  |

| ID | WBS | Task | Duration | Start | Finish | Predecessors | Total slack | Constraint |
| --- | --- | --- | --- | --- | --- | --- | --- | --- |
| 29 | 6 | **WP Integrative Risk Assessment and Feedback** | 1171.29d? | 2008-01-28 | 2011-12-30 |  | 0.03d |  |
| 30 | 6.1 | Disease management strategies for diabetes | 55.97w? | 2008-01-28 | 2009-01-05 |  | 891.45d | start no earlier than 2008-01-28 |
| 31 | 6.2 | Models for risk assessment | 234.25w? | 2008-01-28 | 2011-12-30 |  | 0.03d | finish no earlier than 2011-12-30 |
| 32 | 6.3 | Stratifications and multi-parametric health status profiling | 86.83w? | 2008-07-21 | 2010-01-04 |  | 594.3d | start no earlier than 2008-07-21 |
| 33 | 6.4 | Knowledge discovery and semantic annotation | 197.69w? | 2008-07-21 | 2011-11-14 |  | 40d | start no earlier than 2008-07-21 |
| 34 | 6.5 | Integration and implementation with user feedback | 174.83w? | 2008-01-28 | 2011-01-03 |  | 297.16d | start no earlier than 2008-01-28 |
| 35 | 7 | **WP Security, Privacy and Safety** | 1171.27d? | 2008-01-28 | 2011-12-30 |  | 0.03d |  |
| 36 | 7.1 | Security requirements | 46.83w? | 2008-01-28 | 2008-11-10 |  | 937.15d | start no earlier than 2008-01-28 |
| 37 | 7.2 | Security architecture | 147.4w? | 2008-07-14 | 2010-12-31 |  | 297.16d | start no earlier than 2008-07-14 |
| 38 | 7.3 | User empowerment | 178.26w? | 2008-11-10 | 2011-11-07 |  | 45.72d | start no earlier than 2008-11-10 |
| 39 | 7.4 | Virtualisation | 178.26w? | 2008-11-10 | 2011-11-07 |  | 45.72d | start no earlier than 2008-11-10 |
| 40 | 7.5 | Patient safety and device risk assessment | 234.25w? | 2008-01-28 | 2011-12-30 |  | 0.03d | finish no earlier than 2011-12-30 |
| 41 | 8 | **WP Clinical Practice and Field Trials** | 1171.27d? | 2008-01-28 | 2011-12-30 |  | 0.03d |  |
| 42 | 8.1 | General ward RCT | 177.11w? | 2008-01-28 | 2011-01-14 |  | 285.75d | start no earlier than 2008-01-28 |
| 43 | 8.2 | Outpatient clinical field trial | 186.26w? | 2008-01-28 | 2011-03-14 |  | 240d | start no earlier than 2008-01-28 |
| 44 | 8.3 | Automatic Glucose Control (AGC) | 87.97w? | 2010-07-12 | 2011-12-30 |  | 0.03d | finish no earlier than 2011-12-30 |
| 45 | 9 | **WP Socio-economic Framework** | 1171.3d? | 2008-01-28 | 2012-01-02 |  | 0d |  |
| 46 | 9.1 | Ethical issues | 147.4w? | 2008-07-14 | 2010-12-31 |  | 297.16d | start no earlier than 2008-07-14 |
| 47 | 9.2 | Social issues | 87.97w? | 2008-07-14 | 2010-01-01 |  | 594.31d | start no earlier than 2008-07-14 |
| 48 | 9.3 | Legal and regulatory framework | 234.26w? | 2008-01-28 | 2012-01-02 | 47 | 0d | start no earlier than 2008-01-28 |
| 49 | 9.4 | Healthcare economics and business models | 119.06w? | 2010-01-01 | 2011-12-30 | 48 | 0.03d | finish no earlier than 2011-12-30 |
| 50 | 10 | **WP Platform Integration and Implementation** | 1171.27d? | 2008-01-28 | 2011-12-30 |  | 0.03d |  |
| 51 | 10.1 | Application development platform | 53.69w? | 2008-01-28 | 2008-12-22 |  | 902.85d | start no earlier than 2008-01-28 |
| 52 | 10.2 | Device and network integration and testing | 205.69w? | 2008-07-21 | 2011-12-30 |  | 0.03d | finish no earlier than 2011-12-30 |
| 53 | 10.3 | Backend integration and testing | 190.83w? | 2008-10-20 | 2011-12-30 |  | 0.03d | finish no earlier than 2011-12-30 |
| 54 | 10.4 | Field trials application development | 171.4w? | 2008-07-21 | 2011-06-03 |  | 171.45d | start no earlier than 2008-07-21 |

| ID | WBS | Task | Duration | Start | Finish | Total slack | Constraint |
| --- | --- | --- | --- | --- | --- | --- | --- |
| 55 | 11 | **WP Demonstration** | 302.7d? | 2010-12-27 | 2011-12-30 | 0.03d |  |
| 56 | 11.1 | Demonstration | 60.54w? | 2010-12-27 | 2011-12-30 | 0.03d | finish no earlier than 2011-12-30 |
| 57 | 12 | **WP Dissemination and Exploitation** | 1171.27d? | 2008-01-28 | 2011-12-30 | 0.03d |  |
| 58 | 12.1 | Dissemination | 234.25w? | 2008-01-28 | 2011-12-30 | 0.03d | start no earlier than 2008-01-28 |
| 59 | 12.2 | Contributions to standards | 178.71w? | 2009-01-01 | 2011-12-30 | 0.02d | start no earlier than 2009-01-01 |
| 60 | 12.3 | Exploitation | 130.26w? | 2009-10-26 | 2011-12-30 | 0.03d | finish no earlier than 2011-12-30 |
| 61 | 13 | **WP Training** | 1039.86d? | 2008-07-07 | 2011-12-30 | 0.03d |  |
| 62 | 13.1 | Horizontal project integration | 29.69w? | 2008-07-07 | 2009-01-05 | 891.43d | start no earlier than 2008-07-07 |
| 63 | 13.2 | External training | 179.4w? | 2008-12-29 | 2011-12-30 | 0.02d | start no earlier than 2008-12-29 |
